# PLANTILLA DE MS PROYECT

Schedule from MS Project, 2024-01-08 to 2026-01-27, status date 2024-08-05, costs in S, A marks actual dates.

## Calendars

- Estándar: Mon-Fri 09:00-13:00, 15:00-19:00; Sat-Sun off.

## Resources

| Resource | Unit | Rate |
| --- | --- | --- |
| Topografo |  | 23.94 |
| Asistente de topografo |  | 17.08 |
| Operario |  | 23.94 |
| Oficial |  | 18.89 |
| Peon |  | 17.08 |
| Jalon topografico |  | 1 |
| Nivel topografico |  | 9.75 |
| Teodolito topografico |  | 10.75 |
| Compresora neumatica 250 - 330 pcm 87 hp |  | 65 |
| Martillo neumatico de 29 kg |  | 32.5 |
| Cargador s/llanta 125-135 hp 3 yd3 |  | 175 |
| Excavadora s/orugas 115-165 hp |  | 295 |
| Camion volquete 15 m3 |  | 155 |
| Camion Cisterna 2000 gl (agua) |  | 123 |
| Rodillo Vib. Liso Aut. 7-9 t |  | 127.5 |
| Motoniveladora 125hp |  | 168 |
| Tractor de tiro Mf 265-63 hp |  | 72 |
| Barredora mecanica 10-20 hp |  | 73 |
| Camion Imprimador 1800 gl |  | 134 |
| Rodillo neumat. Aut. 5.5 - 20 t |  | 130 |
| Rodillo Tandem 8-10 t |  | 135 |
| Pavimentadora asfalto s/llantas 10'-16' |  | 165 |
| Compactadora Vib. Tipo plancha 7 hp |  | 48 |
| Rodillo Vib. Liso Aut.1.8 t |  | 55 |
| Material Granular (Subbase) | m3 | 48 |
| Material Granular (base) | m3 | 65 |
| Asfalto Liquido rc-250 | gl | 15 |
| Petroleo diesel N° 1 (kerosene Ind.) | gl | 14 |
| Clavo con Cabeza (promedio) | kg | 6 |
| Concreto Premezclado f'c = 210kg/cm2 t-1 | m3 | 300 |
| Aditivo liquido curador | gl | 23.5 |
| Madera tornillo para carpinteria | p2 | 7 |
| Mezcla asfaltica en caliente | m3 | 495 |
| Transporte de Mezcla asfaltica |  |  |
| Flete Terrestre en Plataforma (ida) |  |  |
| Flete Terrestre en Plataforma (vuelta) |  |  |
| Servicio de alquiler de contenedor |  |  |
| Disolvente Xilol | gl | 29 |
| Servicio de Fab. e Inst. Señal Informativa |  |  |
| Servicio de Fab. e Inst. Señal Octog. Preventiva |  |  |
| Pintura de transito | gl | 85 |
| Herramientas Manuales |  |  |
| Mira Topografica |  | 1.25 |

## Schedule

| ID | WBS | Task | Type | Duration | Start | Finish | Predecessors | Complete | Remaining | Baseline start | Baseline finish | Baseline duration | Baseline 1 start | Baseline 1 finish | Total slack | Free slack | Constraint | Cost | Baseline cost | Actual cost |
| --- | --- | --- | --- | --- | --- | --- | --- | --- | --- | --- | --- | --- | --- | --- | --- | --- | --- | --- | --- | --- |
| 1 | 1 | **CONSTRUCCION VIAL JR. RAMON CASTILLA** |  | 536.5d | 2024-01-08 A | 2026-01-27 |  | 20% | 428.01d | 2023-10-04 | 2024-12-23 | 319d | 2023-10-04 | 2024-12-23 | 0d |  |  | 13,096,436.96 | 13,096,436.96 | 836,590.46 |
| 2 | 1.1 | INICIO | milestone | 0d | 2024-01-08 A | 2024-01-08 A |  | 100% |  | 2023-10-04 | 2023-10-04 | 0d | 2023-10-04 | 2023-10-04 |  |  |  |  |  |  |
| 3 | 1.2 | **Obras Provisionales, trabajos Preliminares, Seguridad y Salud** |  | 213d | 2024-01-08 A | 2024-10-30 |  | 77% | 50.05d | 2023-10-04 | 2024-02-20 | 100d | 2023-10-04 | 2024-02-20 | 44.75d |  |  | 91,801.4 | 91,801.4 | 81,348.85 |
| 4 | 1.2.1 | Movilizacion y desmovilización |  | 30d | 2024-01-08 A | 2024-02-16 A | 2 | 100% |  | 2023-10-04 | 2023-11-14 | 30d | 2023-10-04 | 2023-11-14 |  |  |  | 30,000 | 30,000 | 30,000 |
| 5 | 1.2.2 | Trazo y replanteo |  | 90d | 2024-01-22 A | 2024-10-30 | 4FS-20d | 61% | 35.25d | 2023-10-18 | 2024-02-20 | 90d | 2023-10-18 | 2024-02-20 | 44.75d | 0d |  | 26,801.4 | 26,801.4 | 16,348.85 |
| 6 | 1.2.3 | Instalaciones provisionales |  | 30d | 2024-02-05 A | 2024-07-15 A | 4FS-10d | 100% |  | 2023-11-01 | 2023-12-12 | 30d | 2023-11-01 | 2023-12-12 |  |  |  | 35,000 | 35,000 | 35,000 |
| 7 | 1.3 | **Demoliciones y Movimiento de Tierras** |  | 232d | 2024-02-05 A | 2024-12-24 |  | 28% | 167.95d | 2023-11-01 | 2024-04-15 | 119d | 2023-11-01 | 2024-04-15 | 25.75d |  |  | 3,615,213.12 | 3,615,213.12 | 755,241.61 |
| 8 | 1.3.1 | Demoliciones varias |  | 118d | 2024-02-05 A | 2024-12-23 | 5FS-80d | 38% | 73.25d | 2023-11-01 | 2024-04-12 | 118d | 2023-11-01 | 2024-04-12 | 26.75d | 0d |  | 1,789,113.6 | 1,789,113.6 | 679,863.17 |
| 9 | 1.3.2 | Corte en material suelto para pavimentos |  | 71d | 2024-02-29 A | 2024-11-12 | 8FS-100d, 6FS-15d | 38% | 44.25d | 2023-11-27 | 2024-03-04 | 71d | 2023-11-27 | 2024-03-04 | 0d |  |  | 198,364.32 | 198,364.32 | 75,378.44 |
| 10 | 1.3.3 | Eliminacion de excedente D = 18 km |  | 70d | 2024-09-18 | 2024-12-24 | 9FS-40d |  |  | 2024-01-09 | 2024-04-15 | 70d | 2024-01-09 | 2024-04-15 | 0d |  | start no earlier than 2024-09-11 | 1,627,735.2 | 1,627,735.2 |  |
| 11 | 1.4 | **Pavimentos** |  | 310.5d | 2024-10-30 | 2026-01-07 |  |  |  | 2024-02-20 | 2024-05-22 | 67d | 2024-02-20 | 2024-05-22 | 0d |  |  | 7,468,959.44 | 7,468,959.44 |  |
| 12 | 1.4.1 | Conformacion de subrasante |  | 27d | 2024-10-30 | 2024-12-05 | 10FS-40d |  |  | 2024-02-20 | 2024-03-27 | 27d | 2024-02-20 | 2024-03-27 | 0d |  | start no earlier than 2024-09-11 | 302,865.92 | 302,865.92 |  |
| 13 | 1.4.2 | Subbase granular e = 020 m |  | 41d | 2024-11-08 | 2025-01-03 | 12FS-20d |  |  | 2024-02-29 | 2024-04-25 | 41d | 2024-02-29 | 2024-04-25 | 0d |  | start no earlier than 2024-09-11 | 1,640,509.36 | 1,640,509.36 |  |
| 14 | 1.4.3 | Base granular e = 0.20 m |  | 86d | 2024-11-25 | 2025-05-28 | 13FS-30d |  |  | 2024-03-15 | 2024-05-10 | 41d | 2024-03-15 | 2024-05-10 | 0d |  | start no earlier than 2024-09-11 | 2,058,709.36 | 2,058,709.36 |  |
| 15 | 1.4.4 | Imprimacion asfaltica |  | 20d | 2025-05-06 | 2025-09-24 | 14FS-17d |  |  | 2024-04-18 | 2024-05-15 | 20d | 2024-04-18 | 2024-05-15 | 0d |  |  | 537,610.8 | 537,610.8 |  |
| 16 | 1.4.5 | Carpeta asfaltica en caliente e = 4 cm |  | 25d | 2025-08-28 | 2026-01-07 | 15FS-20d |  |  | 2024-04-18 | 2024-05-22 | 25d | 2024-04-18 | 2024-05-22 | 0d |  |  | 2,929,264 | 2,929,264 |  |
| 17 | 1.5 | **Obras de arte** |  | 233d | 2024-10-01 | 2025-08-21 |  |  |  | 2024-01-22 | 2024-12-11 | 233d | 2024-01-22 | 2024-12-11 | 104.5d |  |  | 1,819,916.7 | 1,819,916.7 |  |
| 18 | 1.5.1 | Excavación en material suelto para veredas y sardineles |  | 182d | 2024-10-01 | 2025-06-16 | 8FS-60d |  |  | 2024-01-22 | 2024-10-04 | 182d | 2024-01-22 | 2024-10-04 | 104.5d | 0d | start no earlier than 2024-09-11 | 222,425.6 | 222,425.6 |  |
| 19 | 1.5.2 | Eliminacion de excedente D = 18 km |  | 13d | 2025-04-15 | 2025-05-01 | 18FS-45d |  |  | 2024-08-05 | 2024-08-21 | 13d | 2024-08-05 | 2024-08-21 | 104.5d | 0d |  | 100,764.56 | 100,764.56 |  |
| 20 | 1.5.3 | Conformacion de subrasante para veredas |  | 22d | 2025-05-02 | 2025-06-02 | 19 |  |  | 2024-08-22 | 2024-09-20 | 22d | 2024-08-22 | 2024-09-20 | 104.5d | 0d |  | 82,337.04 | 82,337.04 |  |
| 21 | 1.5.4 | Base para veredas e = 0.10 m |  | 35d | 2025-06-03 | 2025-07-21 | 20 |  |  | 2024-09-23 | 2024-11-08 | 35d | 2024-09-23 | 2024-11-08 | 104.5d | 0d |  | 429,484.8 | 429,484.8 |  |
| 22 | 1.5.5 | Veredas de concreto fc = 210 kg/cm2, e = 4" |  | 38d | 2025-07-01 | 2025-08-21 | 21FS-15d |  |  | 2024-10-21 | 2024-12-11 | 38d | 2024-10-21 | 2024-12-11 | 104.5d |  |  | 984,904.7 | 984,904.7 |  |
| 23 | 1.6 | **Señalización y Seguridad Vial** |  | 14d | 2026-01-07 | 2026-01-27 |  |  |  | 2024-05-23 | 2024-12-23 | 153d | 2024-05-23 | 2024-12-23 | 0d |  |  | 100,546.3 | 100,546.3 |  |
| 24 | 1.6.1 | Pintura zonal de simbolos y letras |  | 13d | 2026-01-07 | 2026-01-26 | 16 |  |  | 2024-05-23 | 2024-06-10 | 13d | 2024-05-23 | 2024-06-10 | 0d |  |  | 75,746.3 | 75,746.3 |  |
| 25 | 1.6.2 | Señales informativas |  | 5d | 2026-01-15 | 2026-01-22 | 24FS-7d, 22 |  |  | 2024-12-12 | 2024-12-18 | 5d | 2024-12-12 | 2024-12-18 | 0d |  |  | 13,200 | 13,200 |  |
| 26 | 1.6.3 | Señales preventivas octogonales 75 x 75 cm |  | 5d | 2026-01-20 | 2026-01-27 | 25FS-2d |  |  | 2024-12-17 | 2024-12-23 | 5d | 2024-12-17 | 2024-12-23 | 0d |  |  | 11,600 | 11,600 |  |
| 27 | 1.7 | FIN | milestone | 0d | 2026-01-27 | 2026-01-27 | 16, 22, 26 |  |  | 2024-12-23 | 2024-12-23 | 0d | 2024-12-23 | 2024-12-23 | 0d |  |  |  |  |  |
